# neujahrsparty3_manual_abgleich

How a schedule from MS Project changed from version to version. A marks actual dates.

## Version 1 (data date 2005-08-31, saved 2005-09-09, file neujahrsparty3_manual_abgleich.mpp)

| ID | WBS | Task | Duration | Start | Finish | Predecessors | Total float | Constraint |
| --- | --- | --- | --- | --- | --- | --- | --- | --- |
| 1 | 1 | **Neujahrs-Party** | 45.25d? | 2005-10-31 17:00 | 2006-01-03 10:00 |  | 0d |  |
| 2 | 1.1 | **Externe Meilensteine** | 0d | 2005-12-28 08:00 | 2005-12-28 08:00 |  | 0.75d |  |
| 3 |  | Hangarübergabe | 0d | 2005-12-28 08:00 | 2005-12-28 08:00 |  | 0.75d | start no earlier than 2005-12-28 08:00 |
| 4 | 1.2 | **Generelle Vorbereitung** | 7d? | 2005-10-31 17:00 | 2005-11-09 17:00 |  | 5d |  |
| 5 |  | OK zusammenstellen | 2.5d? | 2005-10-31 17:00 | 2005-11-02 21:00 |  | 4d |  |
| 6 |  | Vertrag mit Lokalbesitzer besiegeln | 0.25d? | 2005-10-31 17:00 | 2005-10-31 19:00 |  | 11d |  |
| 7 |  | Generelle Vorbereitungen abgeschlossen | 0d | 2005-11-09 17:00 | 2005-11-09 17:00 | 5FS+5d, 6 | 4d |  |
| 8 | 1.3 | **Catering** | 34.5d? | 2005-11-09 17:00 | 2005-12-28 12:00 |  | 1.5d |  |
| 9 |  | Catering Service bestellen | 0.62d? | 2005-11-09 17:00 | 2005-11-09 22:00 | 7 | 32d |  |
| 10 |  | Catering Service aufstellen | 0.5d? | 2005-12-28 08:00 | 2005-12-28 12:00 | 9FS+2d, 3 | 1.5d |  |
| 11 |  | Catering Service bereit | 0d | 2005-12-28 12:00 | 2005-12-28 12:00 | 10 | 1.5d |  |
| 12 | 1.4 | **Deko-Workshop** | 9d? | 2005-11-09 17:00 | 2005-11-23 01:00 |  | 26d |  |
| 13 |  | Deko-Team zusammenstellen | 2.5d? | 2005-11-09 17:00 | 2005-11-11 21:00 | 7 | 25d |  |
| 14 |  | Erstellen von Dekorationsideen | 1d? | 2005-11-18 17:00 | 2005-11-21 01:00 | 13FS+5d | 25d |  |
| 15 |  | Bereitstellen der Dekorationen | 2d? | 2005-11-21 17:00 | 2005-11-23 01:00 | 14 | 25d |  |
| 16 |  | Deko-Workshop abgeschlossen | 0d | 2005-11-23 01:00 | 2005-11-23 01:00 | 15 | 26d |  |
| 17 | 1.5 | **Marketing** | 31d? | 2005-11-09 17:00 | 2005-12-22 17:00 |  | 5d |  |
| 18 |  | Marketing Team zusammenstellen | 2.5d? | 2005-11-09 17:00 | 2005-11-11 21:00 | 7 | 4d |  |
| 19 |  | Erstellung eines Werbekonzepts | 2d? | 2005-11-18 17:00 | 2005-11-22 01:00 | 18FS+5d | 4d |  |
| 20 |  | Design Werbeflyer | 5d? | 2005-11-22 08:00 | 2005-11-28 17:00 | 19 | 4d |  |
| 21 |  | Design Plakate | 5d? | 2005-11-22 08:00 | 2005-11-28 17:00 | 19 | 4d |  |
| 22 |  | Abnahme Flyer und Plakate | 0.25d? | 2005-11-28 17:00 | 2005-11-28 19:00 | 20, 21 | 4d |  |
| 23 |  | Schaltung von Inseraten | 0.62d? | 2005-11-28 19:00 | 2005-11-29 00:00 | 22 | 7d |  |
| 24 |  | Produktion Flyer und Plakete | 2.5d? | 2005-11-29 08:00 | 2005-12-01 12:00 | 22 | 4.5d |  |
| 25 |  | Auflegen von Flyern | 0.62d? | 2005-12-01 17:00 | 2005-12-01 22:00 | 24 | 4d |  |
| 26 |  | Aufhaengen von Plakaten | 0.75d? | 2005-12-01 17:00 | 2005-12-01 23:00 | 24 | 4d |  |
| 27 |  | Marketing abgeschlossen | 0d | 2005-12-22 17:00 | 2005-12-22 17:00 | 25FS+15d, 23FS+15d, 26FS+15d | 4d |  |
| 28 | 1.6 | **WCs** | 34.38d? | 2005-11-09 17:00 | 2005-12-28 11:00 |  | 1.62d |  |
| 29 |  | Bestellung | 0.25d? | 2005-11-09 17:00 | 2005-11-09 19:00 | 7 | 32d |  |
| 30 |  | Aufstellen | 0.38d? | 2005-12-28 08:00 | 2005-12-28 11:00 | 29FS+2d, 3 | 1.62d |  |
| 31 |  | WCs betriebsbereit | 0d | 2005-12-28 11:00 | 2005-12-28 11:00 | 30 | 1.62d |  |
| 32 | 1.7 | **Security** | 34d? | 2005-11-09 17:00 | 2005-12-28 08:00 |  | 2d |  |
| 33 |  | Bestellung Security Personal | 0.25d? | 2005-11-09 17:00 | 2005-11-09 19:00 | 7 | 34d |  |
| 34 |  | Security betriebsbereit | 0d | 2005-12-28 08:00 | 2005-12-28 08:00 | 33FS+1d, 3 | 2d |  |
| 35 | 1.8 | **Barbetrieb** | 36d? | 2005-11-09 17:00 | 2005-12-29 22:00 |  | 2d |  |
| 36 | 1.8.1 | **Bar** | 35d? | 2005-11-09 17:00 | 2005-12-28 20:00 |  | 3d |  |
| 37 |  | Barelemente bestellen | 0.38d? | 2005-11-09 17:00 | 2005-11-09 20:00 | 7 | 28d |  |
| 38 |  | Anlieferung Barelemente | 0.25d? | 2005-12-28 08:00 | 2005-12-28 10:00 | 3, 37FS+5d | 0.75d |  |
| 39 |  | Elektrische Anschluesse bereitstellen | 0.38d? | 2005-12-28 10:00 | 2005-12-28 14:00 | 38 | 1d |  |
| 40 |  | Anlieferung Kuehlschraenke | 0.12d? | 2005-12-28 14:00 | 2005-12-28 15:00 | 39 | 1d |  |
| 41 |  | Dekoration anbringen | 0.25d? | 2005-12-28 17:00 | 2005-12-28 19:00 | 38 | 0d |  |
| 42 |  | Barbeleuchtung anbringen | 0.12d? | 2005-12-28 19:00 | 2005-12-28 20:00 | 38, 41 | 0d |  |
| 43 |  | Bar abgeschlossen | 0d | 2005-12-28 20:00 | 2005-12-28 20:00 | 40, 41, 42 | 3d |  |
| 44 | 1.8.2 | **Getraenke** | 34.25d? | 2005-11-09 17:00 | 2005-12-28 10:00 |  | 1.5d |  |
| 45 |  | Alkoholausschankgenehmung einholen | 0.12d? | 2005-11-09 17:00 | 2005-11-09 18:00 | 7 | 20d |  |
| 46 |  | Getraenkeauswahl | 0.25d? | 2005-11-09 17:00 | 2005-11-09 19:00 | 7 | 34d |  |
| 47 |  | Getraenkebestellung | 0.12d? | 2005-11-09 19:00 | 2005-11-09 20:00 | 46 | 34d |  |
| 48 |  | Getraenkeanlieferung | 0.25d? | 2005-12-28 08:00 | 2005-12-28 10:00 | 3, 47 | 1.75d |  |
| 49 |  | Getraenke abgeschlossen | 0d | 2005-12-28 10:00 | 2005-12-28 10:00 | 48, 45FS+15d | 1.75d |  |
| 50 | 1.8.3 | **Barpersonal** | 35d? | 2005-11-09 17:00 | 2005-12-28 19:00 |  | 0.75d |  |
| 51 |  | Aufstellen Barpersonal | 1.25d? | 2005-11-09 17:00 | 2005-11-10 19:00 | 7 | 29d |  |
| 52 |  | Einweisung Barpersonal + Verpflegung | 0.25d? | 2005-12-28 17:00 | 2005-12-28 19:00 | 51FS+5d, 3 | 3d |  |
| 53 |  | Barpersonal abgeschlossen | 0d | 2005-12-28 19:00 | 2005-12-28 19:00 | 52 | 1d |  |
| 54 | 1.8.4 | **Sitzecke** | 2d? | 2005-12-28 08:00 | 2005-12-29 22:00 |  | 1d |  |
| 55 |  | Organisation Tische + Stuehle | 0.62d? | 2005-12-28 20:00 | 2005-12-29 01:00 | 3, 7, 42 | 0d |  |
| 56 |  | Elektrische Anschluesse bereitstellen | 0.12d? | 2005-12-28 08:00 | 2005-12-28 09:00 | 7, 3 | 0.88d |  |
| 57 |  | Dekoration anbringen | 0.25d? | 2005-12-29 17:00 | 2005-12-29 19:00 | 55 | 0d |  |
| 58 |  | Beleuchtung | 0.38d? | 2005-12-29 19:00 | 2005-12-29 22:00 | 56, 57 | 0d |  |
| 59 |  | Sitzecke abgeschlossen | 0d | 2005-12-29 22:00 | 2005-12-29 22:00 | 57, 58 | 2d |  |
| 60 |  | Barbetrieb Vorbereitung abgeschlossen | 0d | 2005-12-29 22:00 | 2005-12-29 22:00 | 43, 49, 53, 59 | 2d |  |
| 61 | 1.9 | **Livekonzert** | 38d? | 2005-11-09 17:00 | 2006-01-02 22:00 |  | 0.25d |  |
| 62 | 1.9.1 | **Band** | 35d? | 2005-11-09 17:00 | 2005-12-28 20:00 |  | 0.75d |  |
| 63 |  | Bands anfragen | 1.25d? | 2005-11-09 17:00 | 2005-11-10 19:00 | 7 | 23d |  |
| 64 |  | Band-Entscheid | 0.12d | 2005-11-24 17:00 | 2005-11-24 18:00 | 63FS+10d | 23d |  |
| 65 |  | Soundcheck & Verpflegung | 0.62d? | 2005-12-28 08:00 | 2005-12-28 20:00 | 3, 64 | 0.75d |  |
| 66 |  | Band abgeschlossen | 0d | 2005-12-28 20:00 | 2005-12-28 20:00 | 65 | 0.75d |  |
| 67 | 1.9.2 | **Tanzflaeche** | 3d? | 2005-12-28 08:00 | 2005-12-30 22:00 |  | 1d |  |
| 68 |  | Tanzflaeche beschallen | 0.5d? | 2005-12-28 08:00 | 2005-12-28 12:00 | 3 | 1.25d |  |
| 69 |  | Tanzflaeche ausleuchten | 0.5d? | 2005-12-28 08:00 | 2005-12-28 12:00 | 3 | 1.25d |  |
| 70 |  | Tanzflaeche dekorieren | 1d? | 2005-12-29 22:00 | 2005-12-30 22:00 | 3, 58 | 0d |  |

| ID | WBS | Task | Duration | Start | Finish | Predecessors | Total float |
| --- | --- | --- | --- | --- | --- | --- | --- |
| 71 |  | Tanzflaeche abgeschlossen | 0d | 2005-12-30 22:00 | 2005-12-30 22:00 | 68, 69, 70 | 1d |
| 72 | 1.9.3 | **Buehne** | 38d? | 2005-11-09 17:00 | 2006-01-02 22:00 |  | 0.25d |
| 73 |  | Buehnenelemente bestellen | 0.5d? | 2005-11-09 17:00 | 2005-11-09 21:00 | 7 | 28d |
| 74 |  | Anlieferung Buehnenelemente | 0.25d? | 2005-12-28 08:00 | 2005-12-28 10:00 | 3, 73FS+5d | 0.75d |
| 75 |  | Dekoration anbringen | 1d? | 2005-12-30 22:00 | 2006-01-02 22:00 | 74, 70 | 0d |
| 76 |  | Elektrische Anschluesse bereitstellen | 0.38d? | 2005-12-28 08:00 | 2005-12-28 11:00 | 3 | 1d |
| 77 |  | Buehnenbeleuchtung | 0.25d? | 2005-12-28 11:00 | 2005-12-28 14:00 | 76 | 1.38d |
| 78 |  | Soundsystem installieren | 0.25d? | 2005-12-28 11:00 | 2005-12-28 14:00 | 76 | 1d |
| 79 |  | Soundsystem checken | 0.12d? | 2005-12-28 14:00 | 2005-12-28 15:00 | 78 | 1d |
| 80 |  | Buehne abgeschlossen | 0d | 2006-01-02 22:00 | 2006-01-02 22:00 | 79, 75 | 0d |
| 81 |  | Livekonzert Vorbereitung abgeschlossen | 0d | 2006-01-02 22:00 | 2006-01-02 22:00 | 66, 71, 80 | 0d |
| 82 | 1.10 | **Retortenmusik** | 35d? | 2005-11-09 17:00 | 2005-12-28 18:00 |  | 0.75d |
| 83 |  | Anmeldung bei Suisa | 0.12d? | 2005-11-09 17:00 | 2005-11-09 18:00 | 7 | 34d |
| 84 |  | Suisa Bewilligung eingetroffen | 0d | 2005-11-09 18:00 | 2005-11-09 18:00 | 83 | 34.75d |
| 85 |  | Engagierung DJ | 0.38d? | 2005-11-09 17:00 | 2005-11-09 20:00 | 7 | 34d |
| 86 |  | Soundcheck | 0.25d? | 2005-12-28 08:00 | 2005-12-28 18:00 | 3, 85 | 0.75d |
| 87 |  | Retortenmusik Vorbereitung abgeschlossen | 0d | 2005-12-28 18:00 | 2005-12-28 18:00 | 86, 84 | 0.75d |
| 88 | 1.11 | **Abnahmen** | 0.25d? | 2006-01-02 22:00 | 2006-01-03 10:00 |  | 0d |
| 89 |  | Feuerpolizeiliche Abnahme | 0.5d? | 2006-01-02 22:00 | 2006-01-03 10:00 | 3, 81, 87, 60 | 0d |
| 90 |  | Abnahme durch Lokalbesitzer | 0.25d? | 2006-01-02 22:00 | 2006-01-03 09:00 | 3, 81, 87, 60 | 0d |
| 91 |  | Abnahme abgeschlossen | 0d | 2006-01-03 09:00 | 2006-01-03 09:00 | 90 | 0.12d |
| 92 |  | Party kann steigen | 0d | 2006-01-03 09:00 | 2006-01-03 09:00 | 91, 27 | 0.12d |
| 93 |  | Ferien | 1d? | 2005-10-31 08:00 | 2005-10-31 17:00 |  | 42d |

## Version 2 (data date 2005-09-04, saved 2005-09-09, file neujahrsparty4.mpp)

Last finish 2006-01-03 → 2005-12-31 (-3d).

Changed:

| ID | Task | Start | Finish | Duration | Total float | Predecessors | Other |
| --- | --- | --- | --- | --- | --- | --- | --- |
| 1 | **Neujahrs-Party** |  | 2006-01-03 10:00 → 2005-12-31 14:00 (-3d) | 45.25d? → 44d? |  |  | baseline start none → 2005-10-31 17:00; baseline finish none → 2005-12-30 19:00 |
| 2 | **Externe Meilensteine** |  |  |  | 0.75d → 0d |  | baseline start none → 2005-12-27 08:00; baseline finish none → 2005-12-27 08:00 |
| 3 | Hangarübergabe |  |  |  | 0.75d → 0d |  | baseline start none → 2005-12-27 08:00; baseline finish none → 2005-12-27 08:00 |
| 4 | **Generelle Vorbereitung** |  |  |  | 5d → 1d |  | baseline start none → 2005-10-31 17:00; baseline finish none → 2005-11-09 17:00 |
| 5 | OK zusammenstellen |  |  |  | 4d → 1d |  | baseline start none → 2005-10-31 17:00; baseline finish none → 2005-11-02 21:00 |
| 6 | Vertrag mit Lokalbesitzer besiegeln |  |  |  | 11d → 8d |  | baseline start none → 2005-10-31 17:00; baseline finish none → 2005-10-31 19:00 |
| 7 | Generelle Vorbereitungen abgeschlossen |  |  |  | 4d → 1d |  | baseline start none → 2005-11-09 17:00; baseline finish none → 2005-11-09 17:00 |
| 8 | **Catering** | 2005-11-09 17:00 → 2005-11-09 22:00 |  |  | 1.5d → 2.5d |  | baseline start none → 2005-11-09 21:00; baseline finish none → 2005-12-27 12:00 |
| 9 | Catering Service bestellen | 2005-11-09 17:00 → 2005-11-09 22:00 | 2005-11-09 22:00 → 2005-11-10 19:00 (+1d) |  | 32d → 33d |  | baseline start none → 2005-11-09 21:00; baseline finish none → 2005-11-10 18:00 |
| 10 | Catering Service aufstellen |  |  |  | 1.5d → 2.5d |  | baseline start none → 2005-12-27 08:00; baseline finish none → 2005-12-27 12:00 |
| 11 | Catering Service bereit |  |  |  | 1.5d → 2.5d |  | baseline start none → 2005-12-27 12:00; baseline finish none → 2005-12-27 12:00 |
| 12 | **Deko-Workshop** |  |  |  | 26d → 28d |  | baseline start none → 2005-11-09 17:00; baseline finish none → 2005-11-23 01:00 |
| 13 | Deko-Team zusammenstellen |  |  |  | 25d → 28d |  | baseline start none → 2005-11-09 17:00; baseline finish none → 2005-11-11 21:00 |
| 14 | Erstellen von Dekorationsideen |  |  |  | 25d → 28d |  | baseline start none → 2005-11-18 17:00; baseline finish none → 2005-11-21 01:00 |
| 15 | Bereitstellen der Dekorationen |  |  |  | 25d → 28d |  | baseline start none → 2005-11-21 17:00; baseline finish none → 2005-11-23 01:00 |
| 16 | Deko-Workshop abgeschlossen |  |  |  | 26d → 28d |  | baseline start none → 2005-11-23 01:00; baseline finish none → 2005-11-23 01:00 |
| 17 | **Marketing** |  | 2005-12-22 17:00 → 2005-12-30 17:00 (+8d) | 31d? → 37d? | 5d → 0d |  | baseline start none → 2005-11-09 17:00; baseline finish none → 2005-12-30 17:00 |
| 18 | Marketing Team zusammenstellen |  |  |  | 4d → 1d |  | baseline start none → 2005-11-09 17:00; baseline finish none → 2005-11-11 21:00 |
| 19 | Erstellung eines Werbekonzepts |  |  |  | 4d → 1d |  | baseline start none → 2005-11-18 17:00; baseline finish none → 2005-11-22 01:00 |
| 20 | Design Werbeflyer |  |  |  | 4d → 6d |  | baseline start none → 2005-11-22 08:00; baseline finish none → 2005-11-28 17:00 |
| 21 | Design Plakate | 2005-11-22 08:00 → 2005-11-29 08:00 (+7d) | 2005-11-28 17:00 → 2005-12-05 17:00 (+7d) |  | 4d → 1d |  | baseline start none → 2005-11-29 08:00; baseline finish none → 2005-12-05 17:00 |
| 22 | Abnahme Flyer und Plakate | 2005-11-28 17:00 → 2005-12-05 17:00 (+7d) | 2005-11-28 19:00 → 2005-12-05 19:00 (+7d) |  | 4d → 1d |  | baseline start none → 2005-12-05 17:00; baseline finish none → 2005-12-05 19:00 |
| 23 | Schaltung von Inseraten | 2005-11-28 19:00 → 2005-12-05 19:00 (+7d) | 2005-11-29 00:00 → 2005-12-06 00:00 (+7d) |  | 7d → 4d |  | baseline start none → 2005-12-05 19:00; baseline finish none → 2005-12-06 00:00 |
| 24 | Produktion Flyer und Plakete | 2005-11-29 08:00 → 2005-12-06 08:00 (+7d) | 2005-12-01 12:00 → 2005-12-08 12:00 (+7d) |  | 4.5d → 1.12d |  | baseline start none → 2005-12-06 08:00; baseline finish none → 2005-12-08 12:00 |
| 25 | Auflegen von Flyern | 2005-12-01 17:00 → 2005-12-08 17:00 (+7d) | 2005-12-01 22:00 → 2005-12-08 22:00 (+7d) |  | 4d → 1d |  | baseline start none → 2005-12-08 17:00; baseline finish none → 2005-12-08 22:00 |
| 26 | Aufhaengen von Plakaten | 2005-12-01 17:00 → 2005-12-08 22:00 (+7d) | 2005-12-01 23:00 → 2005-12-09 20:00 (+8d) |  | 4d → 0d |  | baseline start none → 2005-12-08 22:00; baseline finish none → 2005-12-09 20:00 |
| 27 | Marketing abgeschlossen | 2005-12-22 17:00 → 2005-12-30 17:00 (+8d) | 2005-12-22 17:00 → 2005-12-30 17:00 (+8d) |  | 4d → 0d |  | baseline start none → 2005-12-30 17:00; baseline finish none → 2005-12-30 17:00 |
| 28 | **WCs** | 2005-11-09 17:00 → 2005-11-10 19:00 (+1d) |  | 34.38d? → 33.38d? | 1.62d → 2.62d |  | baseline start none → 2005-11-10 18:00; baseline finish none → 2005-12-27 11:00 |
| 29 | Bestellung | 2005-11-09 17:00 → 2005-11-10 19:00 (+1d) | 2005-11-09 19:00 → 2005-11-10 21:00 (+1d) |  | 32d → 33d |  | baseline start none → 2005-11-10 18:00; baseline finish none → 2005-11-10 20:00 |
| 30 | Aufstellen |  |  |  | 1.62d → 2.62d |  | baseline start none → 2005-12-27 08:00; baseline finish none → 2005-12-27 11:00 |
| 31 | WCs betriebsbereit |  |  |  | 1.62d → 2.62d |  | baseline start none → 2005-12-27 11:00; baseline finish none → 2005-12-27 11:00 |
| 32 | **Security** | 2005-11-09 17:00 → 2005-11-10 19:00 (+1d) |  | 34d? → 33d? | 2d → 3d |  | baseline start none → 2005-11-10 18:00; baseline finish none → 2005-12-27 08:00 |
| 33 | Bestellung Security Personal | 2005-11-09 17:00 → 2005-11-10 19:00 (+1d) | 2005-11-09 19:00 → 2005-11-10 21:00 (+1d) |  | 34d → 35d |  | baseline start none → 2005-11-10 18:00; baseline finish none → 2005-11-10 20:00 |
| 34 | Security betriebsbereit |  |  |  | 2d → 3d |  | baseline start none → 2005-12-27 08:00; baseline finish none → 2005-12-27 08:00 |
| 35 | **Barbetrieb** |  | 2005-12-29 22:00 → 2005-12-31 11:00 (+2d) | 36d? → 37d? | 2d → 0d |  | baseline start none → 2005-11-09 17:00; baseline finish none → 2005-12-30 19:00 |
| 36 | **Bar** |  | 2005-12-28 20:00 → 2005-12-30 19:00 (+2d) | 35d? → 37d? | 3d → 0d |  | baseline start none → 2005-11-09 18:00; baseline finish none → 2005-12-29 20:00 |
| 37 | Barelemente bestellen |  |  |  | 28d → 30d |  | baseline start none → 2005-11-09 18:00; baseline finish none → 2005-11-09 21:00 |
| 38 | Anlieferung Barelemente |  |  |  | 0.75d → 1d |  | baseline start none → 2005-12-27 08:00; baseline finish none → 2005-12-27 10:00 |
| 39 | Elektrische Anschluesse bereitstellen |  |  |  | 1d → 2.25d |  | baseline start none → 2005-12-27 10:00; baseline finish none → 2005-12-27 14:00 |
| 40 | Anlieferung Kuehlschraenke |  |  |  | 1d → 2.25d |  | baseline start none → 2005-12-27 14:00; baseline finish none → 2005-12-27 15:00 |
| 41 | Dekoration anbringen | 2005-12-28 17:00 → 2005-12-30 17:00 (+2d) | 2005-12-28 19:00 → 2005-12-30 19:00 (+2d) |  |  |  | baseline start none → 2005-12-29 17:00; baseline finish none → 2005-12-29 19:00 |
| 42 | Barbeleuchtung anbringen | 2005-12-28 19:00 → 2005-12-30 17:00 (+2d) | 2005-12-28 20:00 → 2005-12-30 18:00 (+2d) |  |  | 38, 41 → 38 | baseline start none → 2005-12-29 19:00; baseline finish none → 2005-12-29 20:00 |
| 43 | Bar abgeschlossen | 2005-12-28 20:00 → 2005-12-30 19:00 (+2d) | 2005-12-28 20:00 → 2005-12-30 19:00 (+2d) |  | 3d → 0d |  | baseline start none → 2005-12-29 20:00; baseline finish none → 2005-12-29 20:00 |
| 44 | **Getraenke** |  |  |  | 1.5d → 2.75d |  | baseline start none → 2005-11-09 17:00; baseline finish none → 2005-12-27 10:00 |
| 45 | Alkoholausschankgenehmung einholen |  |  |  | 20d → 22d |  | baseline start none → 2005-11-09 17:00; baseline finish none → 2005-11-09 18:00 |
| 46 | Getraenkeauswahl | 2005-11-09 17:00 → 2005-11-10 19:00 (+1d) | 2005-11-09 19:00 → 2005-11-10 21:00 (+1d) |  | 34d → 35d |  | baseline start none → 2005-11-10 18:00; baseline finish none → 2005-11-10 20:00 |
| 47 | Getraenkebestellung | 2005-11-09 19:00 → 2005-11-10 21:00 (+1d) | 2005-11-09 20:00 → 2005-11-10 22:00 (+1d) |  | 34d → 35d |  | baseline start none → 2005-11-10 20:00; baseline finish none → 2005-11-10 21:00 |
| 48 | Getraenkeanlieferung |  |  |  | 1.75d → 2.75d |  | baseline start none → 2005-12-27 08:00; baseline finish none → 2005-12-27 10:00 |
| 49 | Getraenke abgeschlossen |  |  |  | 1.75d → 2.75d |  | baseline start none → 2005-12-27 10:00; baseline finish none → 2005-12-27 10:00 |
| 50 | **Barpersonal** | 2005-11-09 17:00 → 2005-11-09 20:00 |  |  | 0.75d → 2d |  | baseline start none → 2005-11-09 21:00; baseline finish none → 2005-12-27 19:00 |
| 51 | Aufstellen Barpersonal | 2005-11-09 17:00 → 2005-11-09 20:00 | 2005-11-10 19:00 → 2005-11-10 22:00 |  | 29d → 31d |  | baseline start none → 2005-11-09 21:00; baseline finish none → 2005-11-10 23:00 |
| 52 | Einweisung Barpersonal + Verpflegung |  |  |  | 3d → 2d |  | baseline start none → 2005-12-27 17:00; baseline finish none → 2005-12-27 19:00 |
| 53 | Barpersonal abgeschlossen |  |  |  | 1d → 2d |  | baseline start none → 2005-12-27 19:00; baseline finish none → 2005-12-27 19:00 |
| 54 | **Sitzecke** |  | 2005-12-29 22:00 → 2005-12-31 11:00 (+2d) | 2d? → 3d? | 1d → 0d |  | baseline start none → 2005-11-10 08:00; baseline finish none → 2005-12-30 19:00 |
| 55 | Organisation Tische + Stuehle | 2005-12-28 20:00 → 2005-12-30 17:00 (+2d) | 2005-12-29 01:00 → 2005-12-30 23:00 (+1d) |  |  | 3, 7, 42 → 3, 7 | baseline start none → 2005-12-29 20:00; baseline finish none → 2005-12-30 01:00 |
| 56 | Elektrische Anschluesse bereitstellen |  |  |  | 0.88d → 0d |  | baseline start none → 2005-11-10 08:00; baseline finish none → 2005-11-10 09:00 |
| 57 | Dekoration anbringen | 2005-12-29 17:00 → 2005-12-30 23:00 (+1d) | 2005-12-29 19:00 → 2005-12-31 01:00 (+2d) |  |  |  | baseline start none → 2005-12-30 17:00; baseline finish none → 2005-12-30 19:00 |
| 58 | Beleuchtung | 2005-12-29 19:00 → 2005-12-30 17:00 (+1d) | 2005-12-29 22:00 → 2005-12-31 11:00 (+2d) |  |  | 56, 57 → 56 | baseline start none → 2005-11-10 17:00; baseline finish none → 2005-11-10 20:00 |
| 59 | Sitzecke abgeschlossen | 2005-12-29 22:00 → 2005-12-31 11:00 (+2d) | 2005-12-29 22:00 → 2005-12-31 11:00 (+2d) |  | 2d → 0d |  | baseline start none → 2005-12-30 19:00; baseline finish none → 2005-12-30 19:00 |
| 60 | Barbetrieb Vorbereitung abgeschlossen | 2005-12-29 22:00 → 2005-12-31 11:00 (+2d) | 2005-12-29 22:00 → 2005-12-31 11:00 (+2d) |  | 2d → 0d |  | baseline start none → 2005-12-30 19:00; baseline finish none → 2005-12-30 19:00 |
| 61 | **Livekonzert** |  | 2006-01-02 22:00 → 2005-12-30 01:00 (-3d) | 38d? → 36d? | 0.25d → 1d |  | baseline start none → 2005-11-09 17:00; baseline finish none → 2005-12-29 01:00 |
| 62 | **Band** |  |  |  | 0.75d → 2d |  | baseline start none → 2005-11-09 17:00; baseline finish none → 2005-12-27 20:00 |
| 63 | Bands anfragen |  |  |  | 23d → 26d |  | baseline start none → 2005-11-09 17:00; baseline finish none → 2005-11-10 19:00 |
| 64 | Band-Entscheid |  |  |  | 23d → 26d |  | baseline start none → 2005-11-24 17:00; baseline finish none → 2005-11-24 18:00 |
| 65 | Soundcheck & Verpflegung | 2005-12-28 08:00 → 2005-12-28 17:00 |  | 0.62d? → 0.38d? | 0.75d → 2.5d |  | baseline start none → 2005-12-27 17:00; baseline finish none → 2005-12-27 20:00 |
| 66 | Band abgeschlossen |  |  |  | 0.75d → 2d |  | baseline start none → 2005-12-27 20:00; baseline finish none → 2005-12-27 20:00 |
| 67 | **Tanzflaeche** | 2005-12-28 08:00 → 2005-12-28 09:00 | 2005-12-30 22:00 → 2005-12-29 12:00 (-1d) | 3d? → 1.38d? | 1d → 1.5d |  | baseline start none → 2005-12-27 10:00; baseline finish none → 2005-12-28 12:00 |
| 68 | Tanzflaeche beschallen | 2005-12-28 08:00 → 2005-12-28 09:00 | 2005-12-28 12:00 → 2005-12-28 16:00 |  | 1.25d → 2.12d |  | baseline start none → 2005-12-27 10:00; baseline finish none → 2005-12-27 17:00 |
| 69 | Tanzflaeche ausleuchten | 2005-12-28 08:00 → 2005-12-29 08:00 (+1d) | 2005-12-28 12:00 → 2005-12-29 12:00 (+1d) |  | 1.25d → 1.5d |  | baseline start none → 2005-12-28 08:00; baseline finish none → 2005-12-28 12:00 |
| 70 | Tanzflaeche dekorieren | 2005-12-29 22:00 → 2005-12-28 17:00 (-1d) | 2005-12-30 22:00 → 2005-12-29 01:00 (-1d) |  | 0d → 2d | 3, 58 → 3 | baseline start none → 2005-12-27 17:00; baseline finish none → 2005-12-28 01:00 |

| ID | Task | Start | Finish | Duration | Total float | Predecessors | Other |
| --- | --- | --- | --- | --- | --- | --- | --- |
| 71 | Tanzflaeche abgeschlossen | 2005-12-30 22:00 → 2005-12-29 12:00 (-1d) | 2005-12-30 22:00 → 2005-12-29 12:00 (-1d) |  | 1d → 1.5d |  | baseline start none → 2005-12-28 12:00; baseline finish none → 2005-12-28 12:00 |
| 72 | **Buehne** | 2005-11-09 17:00 → 2005-11-09 18:00 | 2006-01-02 22:00 → 2005-12-30 01:00 (-3d) | 38d? → 36d? | 0.25d → 1d |  | baseline start none → 2005-11-09 17:00; baseline finish none → 2005-12-29 01:00 |
| 73 | Buehnenelemente bestellen | 2005-11-09 17:00 → 2005-11-09 18:00 | 2005-11-09 21:00 → 2005-11-09 22:00 |  | 28d → 30d |  | baseline start none → 2005-11-09 17:00; baseline finish none → 2005-11-09 21:00 |
| 74 | Anlieferung Buehnenelemente |  |  |  | 0.75d → 1.75d |  | baseline start none → 2005-12-27 08:00; baseline finish none → 2005-12-27 10:00 |
| 75 | Dekoration anbringen | 2005-12-30 22:00 → 2005-12-29 17:00 (-1d) | 2006-01-02 22:00 → 2005-12-30 01:00 (-3d) |  | 0d → 1d | 74, 70 → 74 | baseline start none → 2005-12-28 17:00; baseline finish none → 2005-12-29 01:00 |
| 76 | Elektrische Anschluesse bereitstellen |  |  |  | 1d → 1.62d |  | baseline start none → 2005-12-27 08:00; baseline finish none → 2005-12-27 11:00 |
| 77 | Buehnenbeleuchtung | 2005-12-28 11:00 → 2005-12-29 08:00 (+1d) | 2005-12-28 14:00 → 2005-12-29 10:00 (+1d) |  | 1.38d → 1.75d |  | baseline start none → 2005-12-28 08:00; baseline finish none → 2005-12-28 10:00 |
| 78 | Soundsystem installieren |  |  |  | 1d → 2d |  | baseline start none → 2005-12-27 11:00; baseline finish none → 2005-12-27 14:00 |
| 79 | Soundsystem checken | 2005-12-28 14:00 → 2005-12-28 16:00 | 2005-12-28 15:00 → 2005-12-28 17:00 |  | 1d → 2d |  | baseline start none → 2005-12-28 08:00; baseline finish none → 2005-12-28 09:00 |
| 80 | Buehne abgeschlossen | 2006-01-02 22:00 → 2005-12-30 01:00 (-3d) | 2006-01-02 22:00 → 2005-12-30 01:00 (-3d) |  | 0d → 1d |  | baseline start none → 2005-12-29 01:00; baseline finish none → 2005-12-29 01:00 |
| 81 | Livekonzert Vorbereitung abgeschlossen | 2006-01-02 22:00 → 2005-12-30 01:00 (-3d) | 2006-01-02 22:00 → 2005-12-30 01:00 (-3d) |  | 0d → 1d |  | baseline start none → 2005-12-29 01:00; baseline finish none → 2005-12-29 01:00 |
| 82 | **Retortenmusik** | 2005-11-09 17:00 → 2005-11-10 19:00 (+1d) |  | 35d? → 34d? | 0.75d → 2d |  | baseline start none → 2005-11-10 18:00; baseline finish none → 2005-12-27 18:00 |
| 83 | Anmeldung bei Suisa | 2005-11-09 17:00 → 2005-11-10 19:00 (+1d) | 2005-11-09 18:00 → 2005-11-10 20:00 (+1d) |  | 34d → 36d |  | baseline start none → 2005-11-10 18:00; baseline finish none → 2005-11-10 19:00 |
| 84 | Suisa Bewilligung eingetroffen | 2005-11-09 18:00 → 2005-11-10 20:00 (+1d) | 2005-11-09 18:00 → 2005-11-10 20:00 (+1d) |  | 34.75d → 36d |  | baseline start none → 2005-11-10 19:00; baseline finish none → 2005-11-10 19:00 |
| 85 | Engagierung DJ | 2005-11-09 17:00 → 2005-11-10 19:00 (+1d) | 2005-11-09 20:00 → 2005-11-10 22:00 (+1d) |  | 34d → 35d |  | baseline start none → 2005-11-10 18:00; baseline finish none → 2005-11-10 21:00 |
| 86 | Soundcheck |  |  |  | 0.75d → 2d |  | baseline start none → 2005-12-27 09:00; baseline finish none → 2005-12-27 18:00 |
| 87 | Retortenmusik Vorbereitung abgeschlossen |  |  |  | 0.75d → 2d |  | baseline start none → 2005-12-27 18:00; baseline finish none → 2005-12-27 18:00 |
| 88 | **Abnahmen** | 2006-01-02 22:00 → 2005-12-31 11:00 (-2d) | 2006-01-03 10:00 → 2005-12-31 14:00 (-3d) | 0.25d? → 0d? |  |  | baseline start none → 2005-12-29 20:00; baseline finish none → 2005-12-30 10:00 |
| 89 | Feuerpolizeiliche Abnahme | 2006-01-02 22:00 → 2005-12-31 11:00 (-2d) | 2006-01-03 10:00 → 2005-12-31 12:00 (-3d) | 0.5d? → 0.12d? |  |  | baseline start none → 2005-12-29 20:00; baseline finish none → 2005-12-30 10:00 |
| 90 | Abnahme durch Lokalbesitzer | 2006-01-02 22:00 → 2005-12-31 11:00 (-2d) | 2006-01-03 09:00 → 2005-12-31 14:00 (-3d) |  |  |  | baseline start none → 2005-12-29 20:00; baseline finish none → 2005-12-30 09:00 |
| 91 | Abnahme abgeschlossen | 2006-01-03 09:00 → 2005-12-31 14:00 (-3d) | 2006-01-03 09:00 → 2005-12-31 14:00 (-3d) |  | 0.12d → 0d |  | baseline start none → 2005-12-30 09:00; baseline finish none → 2005-12-30 09:00 |
| 92 | Party kann steigen | 2006-01-03 09:00 → 2005-12-31 14:00 (-3d) | 2006-01-03 09:00 → 2005-12-31 14:00 (-3d) |  | 0.12d → 0d |  | baseline start none → 2005-12-30 17:00; baseline finish none → 2005-12-30 17:00 |
| 93 | Ferien |  |  |  | 42d → 44d |  | baseline start none → 2005-10-31 08:00; baseline finish none → 2005-10-31 17:00 |

## Version 3 (data date 2005-12-08, saved 2005-09-09, file neujahrsparty_finish.mpp)

Last finish stays 2005-12-31. Complete tasks 0 → 28.

Added:

| ID | Task | Duration | Start | Finish | Constraint | Resources |
| --- | --- | --- | --- | --- | --- | --- |
| 93 | Elektriker weg | 1d | 2005-12-28 08:00 | 2005-12-28 17:00 | start no earlier than 2005-12-28 08:00 | Elektriker |

Removed: 93 Ferien

Changed:

| ID | Task | Start | Finish | Duration | Complete | Total float | Predecessors | Other |
| --- | --- | --- | --- | --- | --- | --- | --- | --- |
| 1 | **Neujahrs-Party** | 2005-10-31 17:00 A | 2005-12-31 14:00 → 2005-12-31 17:00 | 44d? → 45d? | 0% → 77% |  |  | baseline finish 2005-12-30 19:00 → 2005-12-31 17:00 |
| 2 | **Externe Meilensteine** |  |  |  |  | 0d → 0.75d |  | baseline start 2005-12-27 08:00 → 2005-12-28 08:00; baseline finish 2005-12-27 08:00 → 2005-12-28 08:00 |
| 3 | Hangarübergabe |  |  |  |  | 0d → 0.75d |  | baseline start 2005-12-27 08:00 → 2005-12-28 08:00; baseline finish 2005-12-27 08:00 → 2005-12-28 08:00 |
| 4 | **Generelle Vorbereitung** | 2005-10-31 17:00 A | 2005-11-09 17:00 A |  | 0% → 100% | 1d → none |  |  |
| 5 | OK zusammenstellen | 2005-10-31 17:00 A | 2005-11-02 21:00 A |  | 0% → 100% | 1d → none |  |  |
| 6 | Vertrag mit Lokalbesitzer besiegeln | 2005-10-31 17:00 A | 2005-10-31 19:00 A |  | 0% → 100% | 8d → none |  |  |
| 7 | Generelle Vorbereitungen abgeschlossen | 2005-11-09 17:00 A | 2005-11-09 17:00 A |  | 0% → 100% | 1d → none |  |  |
| 8 | **Catering** | 2005-11-09 22:00 A |  |  | 0% → 56% | 2.5d → 3.5d |  | baseline start 2005-11-09 21:00 → 2005-11-09 22:00; baseline finish 2005-12-27 12:00 → 2005-12-28 12:00 |
| 9 | Catering Service bestellen | 2005-11-09 22:00 A | 2005-11-10 19:00 A |  | 0% → 100% | 33d → none |  | baseline start 2005-11-09 21:00 → 2005-11-09 22:00; baseline finish 2005-11-10 18:00 → 2005-11-10 19:00 |
| 10 | Catering Service aufstellen |  |  |  |  | 2.5d → 3.5d |  | baseline start 2005-12-27 08:00 → 2005-12-28 08:00; baseline finish 2005-12-27 12:00 → 2005-12-28 12:00 |
| 11 | Catering Service bereit |  |  |  |  | 2.5d → 3.5d |  | baseline start 2005-12-27 12:00 → 2005-12-28 12:00; baseline finish 2005-12-27 12:00 → 2005-12-28 12:00 |
| 12 | **Deko-Workshop** | 2005-11-09 17:00 A | 2005-11-23 01:00 A |  | 0% → 100% | 28d → none |  |  |
| 13 | Deko-Team zusammenstellen | 2005-11-09 17:00 A | 2005-11-11 21:00 A |  | 0% → 100% | 28d → none |  |  |
| 14 | Erstellen von Dekorationsideen | 2005-11-18 17:00 A | 2005-11-21 01:00 A |  | 0% → 100% | 28d → none |  |  |
| 15 | Bereitstellen der Dekorationen | 2005-11-21 17:00 A | 2005-11-23 01:00 A |  | 0% → 100% | 28d → none |  |  |
| 16 | Deko-Workshop abgeschlossen | 2005-11-23 01:00 A | 2005-11-23 01:00 A |  | 0% → 100% | 28d → none |  |  |
| 17 | **Marketing** | 2005-11-09 17:00 A | 2005-12-30 17:00 → 2005-12-31 17:00 (+1d) | 37d? → 38d? | 0% → 94% |  |  | baseline finish 2005-12-30 17:00 → 2005-12-31 17:00 |
| 18 | Marketing Team zusammenstellen | 2005-11-09 17:00 A | 2005-11-11 21:00 A |  | 0% → 100% | 1d → none |  |  |
| 19 | Erstellung eines Werbekonzepts | 2005-11-18 17:00 A | 2005-11-22 01:00 A |  | 0% → 100% | 1d → none |  |  |
| 20 | Design Werbeflyer | 2005-11-22 08:00 A | 2005-11-28 17:00 A |  | 0% → 100% | 6d → none |  |  |
| 21 | Design Plakate | 2005-11-29 08:00 A | 2005-12-05 17:00 A |  | 0% → 100% | 1d → none |  |  |
| 22 | Abnahme Flyer und Plakate | 2005-12-05 17:00 A | 2005-12-05 19:00 A |  | 0% → 100% | 1d → none |  |  |
| 23 | Schaltung von Inseraten | 2005-12-05 19:00 A | 2005-12-06 00:00 A |  | 0% → 100% | 4d → none |  |  |
| 24 | Produktion Flyer und Plakete | 2005-12-06 08:00 A | 2005-12-08 12:00 → 2005-12-12 17:00 A (+4d) | 2.5d? → 5d? | 0% → 100% | 1.12d → none |  | resources Druckerei → Druckerei [50%]; baseline finish 2005-12-08 12:00 → 2005-12-12 17:00 |
| 25 | Auflegen von Flyern | 2005-12-08 17:00 → 2005-12-12 17:00 (+4d) | 2005-12-08 22:00 → 2005-12-12 22:00 (+4d) |  |  |  |  | baseline start 2005-12-08 17:00 → 2005-12-12 17:00; baseline finish 2005-12-08 22:00 → 2005-12-12 22:00 |
| 26 | Aufhaengen von Plakaten | 2005-12-08 22:00 → 2005-12-12 22:00 (+4d) | 2005-12-09 20:00 → 2005-12-13 20:00 (+4d) |  |  |  |  | baseline start 2005-12-08 22:00 → 2005-12-12 22:00; baseline finish 2005-12-09 20:00 → 2005-12-13 20:00 |
| 27 | Marketing abgeschlossen | 2005-12-30 17:00 → 2005-12-31 17:00 (+1d) | 2005-12-30 17:00 → 2005-12-31 17:00 (+1d) |  |  |  | 25FS+15d, 23FS+15d, 26FS+15d → 25FS+14d, 23FS+14d, 26FS+14d | baseline start 2005-12-30 17:00 → 2005-12-31 17:00; baseline finish 2005-12-30 17:00 → 2005-12-31 17:00 |
| 28 | **WCs** | 2005-11-10 19:00 A |  |  | 0% → 40% | 2.62d → 3.62d |  | baseline start 2005-11-10 18:00 → 2005-11-10 19:00; baseline finish 2005-12-27 11:00 → 2005-12-28 11:00 |
| 29 | Bestellung | 2005-11-10 19:00 A | 2005-11-10 21:00 A |  | 0% → 100% | 33d → none |  | baseline start 2005-11-10 18:00 → 2005-11-10 19:00; baseline finish 2005-11-10 20:00 → 2005-11-10 21:00 |
| 30 | Aufstellen |  |  |  |  | 2.62d → 3.62d |  | baseline start 2005-12-27 08:00 → 2005-12-28 08:00; baseline finish 2005-12-27 11:00 → 2005-12-28 11:00 |
| 31 | WCs betriebsbereit |  |  |  |  | 2.62d → 3.62d |  | baseline start 2005-12-27 11:00 → 2005-12-28 11:00; baseline finish 2005-12-27 11:00 → 2005-12-28 11:00 |
| 32 | **Security** | 2005-11-10 19:00 A |  |  | 0% → 99% | 3d → 4d |  | baseline start 2005-11-10 18:00 → 2005-11-10 19:00; baseline finish 2005-12-27 08:00 → 2005-12-28 08:00 |
| 33 | Bestellung Security Personal | 2005-11-10 19:00 A | 2005-11-10 21:00 A |  | 0% → 100% | 35d → none |  | baseline start 2005-11-10 18:00 → 2005-11-10 19:00; baseline finish 2005-11-10 20:00 → 2005-11-10 21:00 |
| 34 | Security betriebsbereit |  |  |  |  | 3d → 4d |  | baseline start 2005-12-27 08:00 → 2005-12-28 08:00; baseline finish 2005-12-27 08:00 → 2005-12-28 08:00 |
| 35 | **Barbetrieb** | 2005-11-09 17:00 A | 2005-12-31 11:00 → 2005-12-31 12:00 | 37d? → 37.5d? | 0% → 41% | 0d → 0.38d |  | baseline finish 2005-12-30 19:00 → 2005-12-29 22:00 |
| 36 | **Bar** | 2005-11-09 17:00 A | 2005-12-30 19:00 → 2005-12-31 00:00 (+1d) |  | 0% → 25% | 0d → 0.88d |  | baseline start 2005-11-09 18:00 → 2005-11-09 17:00; baseline finish 2005-12-29 20:00 → 2005-12-28 20:00 |
| 37 | Barelemente bestellen | 2005-11-09 17:00 A | 2005-11-09 20:00 A |  | 0% → 100% | 30d → none |  | baseline start 2005-11-09 18:00 → 2005-11-09 17:00; baseline finish 2005-11-09 21:00 → 2005-11-09 20:00 |
| 38 | Anlieferung Barelemente |  |  |  |  | 1d → 0.88d |  | baseline start 2005-12-27 08:00 → 2005-12-28 08:00; baseline finish 2005-12-27 10:00 → 2005-12-28 10:00 |
| 39 | Elektrische Anschluesse bereitstellen | 2005-12-28 10:00 → 2005-12-29 08:00 (+1d) | 2005-12-28 14:00 → 2005-12-29 11:00 (+1d) |  |  | 2.25d → 2.38d |  | baseline start 2005-12-27 10:00 → 2005-12-28 10:00; baseline finish 2005-12-27 14:00 → 2005-12-28 14:00 |
| 40 | Anlieferung Kuehlschraenke | 2005-12-28 14:00 → 2005-12-29 11:00 (+1d) | 2005-12-28 15:00 → 2005-12-29 12:00 (+1d) |  |  | 2.25d → 2.38d |  | baseline start 2005-12-27 14:00 → 2005-12-28 14:00; baseline finish 2005-12-27 15:00 → 2005-12-28 15:00 |
| 41 | Dekoration anbringen | 2005-12-30 17:00 → 2005-12-30 21:00 | 2005-12-30 19:00 → 2005-12-30 23:00 |  |  | 0d → 0.62d |  | baseline start 2005-12-29 17:00 → 2005-12-28 17:00; baseline finish 2005-12-29 19:00 → 2005-12-28 19:00 |
| 42 | Barbeleuchtung anbringen | 2005-12-30 17:00 → 2005-12-30 23:00 | 2005-12-30 18:00 → 2005-12-31 00:00 (+1d) |  |  | 0d → 0.75d |  | baseline start 2005-12-29 19:00 → 2005-12-28 19:00; baseline finish 2005-12-29 20:00 → 2005-12-28 20:00 |
| 43 | Bar abgeschlossen | 2005-12-30 19:00 → 2005-12-31 00:00 (+1d) | 2005-12-30 19:00 → 2005-12-31 00:00 (+1d) |  |  | 0d → 0.88d |  | baseline start 2005-12-29 20:00 → 2005-12-28 20:00; baseline finish 2005-12-29 20:00 → 2005-12-28 20:00 |
| 44 | **Getraenke** | 2005-11-09 17:00 A |  |  | 0% → 67% | 2.75d → 3.62d |  | baseline finish 2005-12-27 10:00 → 2005-12-28 10:00 |
| 45 | Alkoholausschankgenehmung einholen | 2005-11-09 17:00 A | 2005-11-09 18:00 A |  | 0% → 100% | 22d → none |  |  |
| 46 | Getraenkeauswahl | 2005-11-10 19:00 A | 2005-11-10 21:00 A |  | 0% → 100% | 35d → none |  | baseline start 2005-11-10 18:00 → 2005-11-10 19:00; baseline finish 2005-11-10 20:00 → 2005-11-10 21:00 |
| 47 | Getraenkebestellung | 2005-11-10 21:00 A | 2005-11-10 22:00 A |  | 0% → 100% | 35d → none |  | baseline start 2005-11-10 20:00 → 2005-11-10 21:00; baseline finish 2005-11-10 21:00 → 2005-11-10 22:00 |
| 48 | Getraenkeanlieferung |  |  |  |  | 2.75d → 3.62d |  | baseline start 2005-12-27 08:00 → 2005-12-28 08:00; baseline finish 2005-12-27 10:00 → 2005-12-28 10:00 |
| 49 | Getraenke abgeschlossen |  |  |  |  | 2.75d → 3.62d |  | baseline start 2005-12-27 10:00 → 2005-12-28 10:00; baseline finish 2005-12-27 10:00 → 2005-12-28 10:00 |
| 50 | **Barpersonal** | 2005-11-09 20:00 A |  |  | 0% → 83% | 2d → 2.88d |  | baseline start 2005-11-09 21:00 → 2005-11-09 20:00; baseline finish 2005-12-27 19:00 → 2005-12-28 19:00 |
| 51 | Aufstellen Barpersonal | 2005-11-09 20:00 A | 2005-11-10 22:00 A |  | 0% → 100% | 31d → none |  | baseline start 2005-11-09 21:00 → 2005-11-09 20:00; baseline finish 2005-11-10 23:00 → 2005-11-10 22:00 |
| 52 | Einweisung Barpersonal + Verpflegung |  |  |  |  |  |  | baseline start 2005-12-27 17:00 → 2005-12-28 17:00; baseline finish 2005-12-27 19:00 → 2005-12-28 19:00 |
| 53 | Barpersonal abgeschlossen |  |  |  |  | 2d → 2.88d |  | baseline start 2005-12-27 19:00 → 2005-12-28 19:00; baseline finish 2005-12-27 19:00 → 2005-12-28 19:00 |
| 54 | **Sitzecke** | 2005-12-28 08:00 → 2005-12-28 17:00 | 2005-12-31 11:00 → 2005-12-31 12:00 | 3d? → 2.5d? |  |  |  | baseline start 2005-11-10 08:00 → 2005-12-28 08:00; baseline finish 2005-12-30 19:00 → 2005-12-29 22:00 |
| 55 | Organisation Tische + Stuehle | 2005-12-30 17:00 → 2005-12-28 17:00 (-2d) | 2005-12-30 23:00 → 2005-12-28 22:00 (-2d) |  |  |  |  | baseline start 2005-12-29 20:00 → 2005-12-28 20:00; baseline finish 2005-12-30 01:00 → 2005-12-29 01:00 |
| 56 | Elektrische Anschluesse bereitstellen | 2005-12-28 08:00 → 2005-12-29 08:00 (+1d) | 2005-12-28 09:00 → 2005-12-29 09:00 (+1d) |  |  | 0d → 1.38d |  | baseline start 2005-11-10 08:00 → 2005-12-28 08:00; baseline finish 2005-11-10 09:00 → 2005-12-28 09:00 |
| 57 | Dekoration anbringen | 2005-12-30 23:00 → 2005-12-31 10:00 (+1d) | 2005-12-31 01:00 → 2005-12-31 12:00 |  |  | 0d → 0.38d |  | baseline start 2005-12-30 17:00 → 2005-12-29 17:00; baseline finish 2005-12-30 19:00 → 2005-12-29 19:00 |
| 58 | Beleuchtung | 2005-12-30 17:00 → 2005-12-30 18:00 | 2005-12-31 11:00 → 2005-12-30 21:00 (-1d) |  |  | 0d → 0.5d |  | baseline start 2005-11-10 17:00 → 2005-12-29 19:00; baseline finish 2005-11-10 20:00 → 2005-12-29 22:00 |
| 59 | Sitzecke abgeschlossen | 2005-12-31 11:00 → 2005-12-31 12:00 | 2005-12-31 11:00 → 2005-12-31 12:00 |  |  | 0d → 0.38d |  | baseline start 2005-12-30 19:00 → 2005-12-29 22:00; baseline finish 2005-12-30 19:00 → 2005-12-29 22:00 |
| 60 | Barbetrieb Vorbereitung abgeschlossen | 2005-12-31 11:00 → 2005-12-31 12:00 | 2005-12-31 11:00 → 2005-12-31 12:00 |  |  | 0d → 0.38d |  | baseline start 2005-12-30 19:00 → 2005-12-29 22:00; baseline finish 2005-12-30 19:00 → 2005-12-29 22:00 |
| 61 | **Livekonzert** | 2005-11-09 17:00 A | 2005-12-30 01:00 → 2005-12-30 18:00 | 36d? → 37d? | 0% → 29% |  |  | baseline finish 2005-12-29 01:00 → 2005-12-31 16:00 |
| 62 | **Band** | 2005-11-09 17:00 A |  |  | 0% → 79% | 2d → 2.88d |  | baseline finish 2005-12-27 20:00 → 2005-12-28 20:00 |
| 63 | Bands anfragen | 2005-11-09 17:00 A | 2005-11-10 19:00 A |  | 0% → 100% | 26d → none |  |  |
| 64 | Band-Entscheid | 2005-11-24 17:00 A | 2005-11-24 18:00 A |  | 0% → 100% | 26d → none |  |  |
| 65 | Soundcheck & Verpflegung |  |  |  |  |  |  | baseline start 2005-12-27 17:00 → 2005-12-28 17:00; baseline finish 2005-12-27 20:00 → 2005-12-28 20:00 |
| 66 | Band abgeschlossen |  |  |  |  | 2d → 2.88d |  | baseline start 2005-12-27 20:00 → 2005-12-28 20:00; baseline finish 2005-12-27 20:00 → 2005-12-28 20:00 |
| 67 | **Tanzflaeche** |  | 2005-12-29 12:00 → 2005-12-30 01:00 (+1d) | 1.38d? → 1.88d? |  | 1.5d → 1.88d |  | baseline start 2005-12-27 10:00 → 2005-12-28 09:00; baseline finish 2005-12-28 12:00 → 2005-12-30 22:00 |
| 68 | Tanzflaeche beschallen |  | 2005-12-28 16:00 → 2005-12-28 14:00 |  |  | 2.12d → 3.25d |  | baseline start 2005-12-27 10:00 → 2005-12-28 09:00; baseline finish 2005-12-27 17:00 → 2005-12-28 16:00 |
| 69 | Tanzflaeche ausleuchten | 2005-12-29 08:00 → 2005-12-28 14:00 (-1d) | 2005-12-29 12:00 → 2005-12-29 09:00 |  |  | 1.5d → 2.75d |  | baseline start 2005-12-28 08:00 → 2005-12-29 08:00; baseline finish 2005-12-28 12:00 → 2005-12-29 12:00 |
| 70 | Tanzflaeche dekorieren | 2005-12-28 17:00 → 2005-12-29 17:00 (+1d) | 2005-12-29 01:00 → 2005-12-30 01:00 (+1d) |  |  | 2d → 1d |  | baseline start 2005-12-27 17:00 → 2005-12-29 22:00; baseline finish 2005-12-28 01:00 → 2005-12-30 22:00 |

| ID | Task | Start | Finish | Duration | Complete | Total float | Other |
| --- | --- | --- | --- | --- | --- | --- | --- |
| 71 | Tanzflaeche abgeschlossen | 2005-12-29 12:00 → 2005-12-30 01:00 (+1d) | 2005-12-29 12:00 → 2005-12-30 01:00 (+1d) |  |  | 1.5d → 1.88d | baseline start 2005-12-28 12:00 → 2005-12-30 22:00; baseline finish 2005-12-28 12:00 → 2005-12-30 22:00 |
| 72 | **Buehne** | 2005-11-09 18:00 A | 2005-12-30 01:00 → 2005-12-30 18:00 | 36d? → 37d? | 0% → 18% |  | baseline start 2005-11-09 17:00 → 2005-11-09 18:00; baseline finish 2005-12-29 01:00 → 2005-12-31 16:00 |
| 73 | Buehnenelemente bestellen | 2005-11-09 18:00 A | 2005-11-09 22:00 A |  | 0% → 100% | 30d → none | baseline start 2005-11-09 17:00 → 2005-11-09 18:00; baseline finish 2005-11-09 21:00 → 2005-11-09 22:00 |
| 74 | Anlieferung Buehnenelemente |  |  |  |  | 1.75d → 0.75d | baseline start 2005-12-27 08:00 → 2005-12-28 08:00; baseline finish 2005-12-27 10:00 → 2005-12-28 10:00 |
| 75 | Dekoration anbringen | 2005-12-29 17:00 → 2005-12-30 10:00 (+1d) | 2005-12-30 01:00 → 2005-12-30 18:00 |  |  | 1d → 0.75d | baseline start 2005-12-28 17:00 → 2005-12-30 22:00; baseline finish 2005-12-29 01:00 → 2005-12-31 16:00 |
| 76 | Elektrische Anschluesse bereitstellen | 2005-12-28 08:00 → 2005-12-29 08:00 (+1d) | 2005-12-28 11:00 → 2005-12-29 11:00 (+1d) |  |  | 1.62d → 2.12d | baseline start 2005-12-27 08:00 → 2005-12-28 08:00; baseline finish 2005-12-27 11:00 → 2005-12-28 11:00 |
| 77 | Buehnenbeleuchtung | 2005-12-29 08:00 → 2005-12-29 11:00 | 2005-12-29 10:00 → 2005-12-29 14:00 |  |  | 1.75d → 2.38d | baseline start 2005-12-28 08:00 → 2005-12-29 08:00; baseline finish 2005-12-28 10:00 → 2005-12-29 10:00 |
| 78 | Soundsystem installieren | 2005-12-28 11:00 → 2005-12-29 11:00 (+1d) | 2005-12-28 14:00 → 2005-12-29 14:00 (+1d) |  |  | 2d → 2.12d | baseline start 2005-12-27 11:00 → 2005-12-28 11:00; baseline finish 2005-12-27 14:00 → 2005-12-28 14:00 |
| 79 | Soundsystem checken | 2005-12-28 16:00 → 2005-12-29 14:00 (+1d) | 2005-12-28 17:00 → 2005-12-29 15:00 (+1d) |  |  | 2d → 2.12d | baseline start 2005-12-28 08:00 → 2005-12-28 16:00; baseline finish 2005-12-28 09:00 → 2005-12-28 17:00 |
| 80 | Buehne abgeschlossen | 2005-12-30 01:00 → 2005-12-30 18:00 | 2005-12-30 01:00 → 2005-12-30 18:00 |  |  | 1d → 0.88d | baseline start 2005-12-29 01:00 → 2005-12-31 16:00; baseline finish 2005-12-29 01:00 → 2005-12-31 16:00 |
| 81 | Livekonzert Vorbereitung abgeschlossen | 2005-12-30 01:00 → 2005-12-30 18:00 | 2005-12-30 01:00 → 2005-12-30 18:00 |  |  | 1d → 0.88d | baseline start 2005-12-29 01:00 → 2005-12-31 16:00; baseline finish 2005-12-29 01:00 → 2005-12-31 16:00 |
| 82 | **Retortenmusik** | 2005-11-10 19:00 A |  |  | 0% → 67% | 2d → 2.88d | baseline start 2005-11-10 18:00 → 2005-11-10 19:00; baseline finish 2005-12-27 18:00 → 2005-12-28 18:00 |
| 83 | Anmeldung bei Suisa | 2005-11-10 19:00 A | 2005-11-10 20:00 A |  | 0% → 100% | 36d → none | baseline start 2005-11-10 18:00 → 2005-11-10 19:00; baseline finish 2005-11-10 19:00 → 2005-11-10 20:00 |
| 84 | Suisa Bewilligung eingetroffen | 2005-11-10 20:00 A | 2005-11-10 20:00 A |  | 0% → 100% | 36d → none | baseline start 2005-11-10 19:00 → 2005-11-10 20:00; baseline finish 2005-11-10 19:00 → 2005-11-10 20:00 |
| 85 | Engagierung DJ | 2005-11-10 19:00 A | 2005-11-10 22:00 A |  | 0% → 100% | 35d → none | baseline start 2005-11-10 18:00 → 2005-11-10 19:00; baseline finish 2005-11-10 21:00 → 2005-11-10 22:00 |
| 86 | Soundcheck |  |  |  |  | 2d → 2.88d | baseline start 2005-12-27 09:00 → 2005-12-28 08:00; baseline finish 2005-12-27 18:00 → 2005-12-28 18:00 |
| 87 | Retortenmusik Vorbereitung abgeschlossen |  |  |  |  | 2d → 2.88d | baseline start 2005-12-27 18:00 → 2005-12-28 18:00; baseline finish 2005-12-27 18:00 → 2005-12-28 18:00 |
| 88 | **Abnahmen** | 2005-12-31 11:00 → 2005-12-31 13:00 |  | 0d? → 0.12d? |  | 0d → 0.38d | baseline start 2005-12-29 20:00 → 2005-12-31 16:00; baseline finish 2005-12-30 10:00 → 2005-12-31 17:00 |
| 89 | Feuerpolizeiliche Abnahme | 2005-12-31 11:00 → 2005-12-31 13:00 | 2005-12-31 12:00 → 2005-12-31 14:00 |  |  | 0d → 0.38d | baseline start 2005-12-29 20:00 → 2005-12-31 16:00; baseline finish 2005-12-30 10:00 → 2005-12-31 17:00 |
| 90 | Abnahme durch Lokalbesitzer | 2005-12-31 11:00 → 2005-12-31 13:00 |  | 0.25d? → 0.12d? |  | 0d → 0.38d | baseline start 2005-12-29 20:00 → 2005-12-31 16:00; baseline finish 2005-12-30 09:00 → 2005-12-31 17:00 |
| 91 | Abnahme abgeschlossen |  |  |  |  | 0d → 0.38d | baseline start 2005-12-30 09:00 → 2005-12-31 17:00; baseline finish 2005-12-30 09:00 → 2005-12-31 17:00 |
| 92 | Party kann steigen | 2005-12-31 14:00 → 2005-12-31 17:00 | 2005-12-31 14:00 → 2005-12-31 17:00 |  |  |  | baseline start 2005-12-30 17:00 → 2005-12-31 17:00; baseline finish 2005-12-30 17:00 → 2005-12-31 17:00 |
